Schedule from MS Project, 2016-07-04 to 2016-09-16, 7 hours a day, costs in S/..
Microsoft

## Calendars

- PS-315: Mon-Fri 09:00-13:00, 15:00-19:00; Sat-Sun 08:00-12:00, 13:00-15:00.

## Schedule

| ID | WBS | Task | Duration | Start | Finish | Predecessors | Total slack | Free slack | Constraint | Cost |
| --- | --- | --- | --- | --- | --- | --- | --- | --- | --- | --- |
| 1 | 1 | **PERFORACION POZO SUSTITUTO PS-315 Y CONSTRUCCION DE CASETA** | 79.43d | 2016-07-04 | 2016-09-16 |  | 0d |  |  | 425,901.14 |
| 2 | 1.1 | **OBRAS PROVISIONALES Y PRELIMINARES** | 79.43d | 2016-07-04 | 2016-09-16 |  | 0d |  |  | 109,092.86 |
| 3 | 1.1.1 | Campamento provisional para la obra | 2d | 2016-07-05 | 2016-07-07 | 4 | 76d |  |  | 2,519.99 |
| 4 | 1.1.2 | Movilización de campamentos,maquinarias, herramientas para la obra | 2d | 2016-07-04 | 2016-07-05 |  | 0.71d | 0d |  | 3,460.82 |
| 5 | 1.1.3 | Cartel de identificación de la obra de 3.60 m x 2.40 m | 1d | 2016-07-05 | 2016-07-06 | 4 | 77d |  |  | 2,037.71 |
| 6 | 1.1.4 | Seguridad, Higiene Ocupacional y Mitigacion de Impactos Ambientales - Obras Civiles | 7d | 2016-07-06 | 2016-09-16 | 4 | 0d |  | finish no earlier than 2016-09-16 | 6,190.49 |
| 7 | 1.1.5 | Servicio de mantenimiento de agua potable por interrupcion del servicio (incl. Transporte y reparto) | 70d | 2016-07-07 | 2016-09-10 | 5 | 6d |  | start no earlier than 2016-07-07 | 94,883.85 |
| 8 | 1.2 | **PERFORACION DE POZO TUBULAR PS-315 (PROF.=100 m)** | 36d | 2016-07-06 | 2016-08-09 |  | 1.43d |  |  | 227,234.47 |
| 9 | 1.2.1 | Transporte, instalación y retiro del equipo de perforación | 2d | 2016-07-06 | 2016-07-08 | 131FS-1d | 75d |  |  | 3,299.79 |
| 10 | 1.2.2 | Limpieza, nivelación del terreno y eliminación del desmonte | 1d | 2016-07-07 | 2016-07-08 | 131 | 0.43d | 0d |  | 1,436.05 |
| 11 | 1.2.3 | Perforación del pozo en diámetro DN 525 (incluye tubería herramientas) | 25d | 2016-07-07 | 2016-07-31 | 10SS | 0.43d | 0d |  | 69,070 |
| 12 | 1.2.4 | Suministro e instalación de tubería para columna de acero DN 375 e=6,35 mm | 25d | 2016-07-07 | 2016-07-31 | 11SS | 51d |  |  | 40,429.35 |
| 13 | 1.2.5 | Suministro e instalación de filtro inoxidable puente trapezoidal DN 375 | 25d | 2016-07-07 | 2016-07-31 | 11SS | 51d |  |  | 34,107.5 |
| 14 | 1.2.6 | Suministro e instalación de tubería fo. galvanizado DN 80 para columna de grava | 4d | 2016-07-24 | 2016-07-28 | 15SS+16d | 53.43d |  |  | 2,456.64 |
| 15 | 1.2.7 | Provisión y colocación de grava selecta para pre filtro | 20d | 2016-07-09 | 2016-07-28 | 11SS+2d | 51d | 0d |  | 6,025 |
| 16 | 1.2.8 | Desarrollo del pozo por pisoneo y/o aire comprimido | 5d | 2016-07-26 | 2016-07-31 | 15SS+18d | 50.43d | 0d |  | 16,289.28 |
| 17 | 1.2.9 | Provisión y colocación de tripolifosfato sódico | 5d | 2016-07-26 | 2016-07-31 | 16SS | 51d |  |  | 2,671.5 |
| 18 | 1.2.10 | Registros de diagrafía pozo:resistividad y rayos gamma 1 cada de uno | 20d | 2016-07-07 | 2016-07-26 | 11SS | 53d | 0d |  | 1,800 |
| 19 | 1.2.11 | Análisis granulométrico del pozo tubular | 15d | 2016-07-12 | 2016-07-26 | 18SS+5d | 53d | 0d |  | 992 |
| 20 | 1.2.12 | Análisis físico-químico y bacteriológico del pozo (1 de cada uno) | 10d | 2016-07-19 | 2016-07-29 | 19SS+8d | 53d |  |  | 500 |
| 21 | 1.2.13 | Prueba de verticalidad y alineamiento del pozo | 15d | 2016-07-12 | 2016-07-26 | 11SS+5d | 56d |  |  | 1,732 |
| 22 | 1.2.14 | Transporte, instalación y retiro del equipo de bombeo incl/columna del pozo | 7d | 2016-08-01 | 2016-08-07 | 25 | 0.43d | 0d |  | 9,653.68 |
| 23 | 1.2.15 | Pruebas de bombeo del pozo | 5d | 2016-08-02 | 2016-08-06 | 22SS+1d | 0.43d | 0d |  | 31,021.2 |
| 24 | 1.2.16 | Evacuación del agua por prueba de bombeo hasta 50 m de distancia (Buzon de Red Principal) | 5d | 2016-08-02 | 2016-08-06 | 23SS | 44d |  |  | 838.93 |
| 25 | 1.2.17 | Sello sanitario en espacio anular entre diámetros de 21" y 15" | 1d | 2016-07-31 | 2016-08-01 | 11 | 0.43d | 0d |  | 179.31 |
| 26 | 1.2.18 | Anillo de concreto armado en espacio entre diámetros de 40" y 21" | 1d | 2016-08-06 | 2016-08-07 | 23 | 0.43d | 0d |  | 2,102.67 |
| 27 | 1.2.19 | Sellado con cemento en fondo del pozo tubular | 1d | 2016-08-01 | 2016-08-02 | 25 | 49d |  |  | 619.28 |
| 28 | 1.2.20 | Desinfección del pozo tubular | 1d | 2016-08-05 | 2016-08-06 | 23SS+4d | 44d |  |  | 255.7 |
| 29 | 1.2.21 | Sello metálico de la boca del pozo tubular | 1d | 2016-08-07 | 2016-08-08 | 26 | 0.43d | 0d |  | 265.27 |
| 30 | 1.2.22 | Limpieza, nivelación del terreno, eliminación del desmonte y restitucion del terreno a su estado original | 1d | 2016-08-08 | 2016-08-09 | 29 | 0.43d | 0d |  | 1,489.32 |

| ID | WBS | Task | Duration | Start | Finish | Predecessors | Total slack | Free slack | Constraint | Cost |
| --- | --- | --- | --- | --- | --- | --- | --- | --- | --- | --- |
| 31 | 1.3 | **EQUIPAMIENTO HIDRAULICO** | 15d | 2016-09-01 | 2016-09-15 |  | 1.57d |  |  | 15,885.8 |
| 32 | 1.3.1 | Unión de desmontaje tipo dresser de hierro dúctil PN 16 DN 150 | 1d | 2016-09-07 | 2016-09-08 | 36SS+1d | 9d |  |  | 468.8 |
| 33 | 1.3.2 | Codo de acero de 45° tipo bridado (BB) DN 150 | 5d | 2016-09-06 | 2016-09-11 | 36SS | 6d |  |  | 2,620.85 |
| 34 | 1.3.3 | Yee de hierro dúctil con 3 bridas PN 16 DN 150 x 150 | 1d | 2016-09-11 | 2016-09-12 | 40SS+1d | 3.43d | 0d |  | 992.44 |
| 35 | 1.3.4 | Tapón de acero o brida ciega para empernar DN 150 | 1d | 2016-09-12 | 2016-09-13 | 34 | 4d |  |  | 121.79 |
| 36 | 1.3.5 | Niple de acero SCH 40 BB DN 150 mm PN 16 (L=0.75 m) | 2d | 2016-09-06 | 2016-09-08 | 75 | 3.43d | 0d |  | 166.84 |
| 37 | 1.3.6 | Niple de acero SCH 40 BB DN 150 mm PN 16 (L=1.05 m) | 2d | 2016-09-06 | 2016-09-08 | 46 | 4d | 0d |  | 215.85 |
| 38 | 1.3.7 | Niple de acero SCH 40 BB DN 150 mm PN 16 (L=1.20 m) | 2d | 2016-09-08 | 2016-09-10 | 37 | 4d | 0d |  | 270.7 |
| 39 | 1.3.8 | Niple de acero SCH 40 BB DN 150 mm PN 16 (L=2.27 m) | 2d | 2016-09-08 | 2016-09-10 | 38SS | 4d | 0d |  | 329.12 |
| 40 | 1.3.9 | Niple de acero SCH 40 BB DN 150 mm PN 16 (L=2.40 m) | 2d | 2016-09-10 | 2016-09-12 | 39 | 4d | 0d |  | 342.9 |
| 41 | 1.3.10 | Brida de acero para soldar y empernar DN 150 | 4d | 2016-09-08 | 2016-09-12 | 36 | 3.43d | 0d |  | 1,324.1 |
| 42 | 1.3.11 | Empaquetadura de jebe enlonada DN 150 | 4d | 2016-09-08 | 2016-09-12 | 41SS | 5d | 0d |  | 129.92 |
| 43 | 1.3.12 | Perno de acero incluye tuerca para unir bridas DN 150 | 4d | 2016-09-08 | 2016-09-12 | 42SS | 5d |  |  | 218.4 |
| 44 | 1.3.13 | Plancha metálica de 29"x29"x1" para sellado de pozo | 1d | 2016-09-11 | 2016-09-12 | 34SS | 5d |  |  | 479.39 |
| 45 | 1.3.14 | Válvula compuerta de fierro fundido tipo bridada DN 150 | 1d | 2016-09-12 | 2016-09-13 | 41 | 3.43d |  |  | 605.55 |
| 46 | 1.3.15 | Dado de Concreto f'c=210 kg/cm2 | 1d | 2016-09-06 | 2016-09-06 | 75SS+1d | 3.43d | 0d |  | 285.09 |
| 47 | 1.3.16 | Montaje de instalacion Hidraulica | 15d | 2016-09-01 | 2016-09-15 |  | 1.57d |  | start no earlier than 2016-09-01 | 7,314.06 |
| 48 | 1.4 | **CONSTRUCCION DE CASETA DE VALVULAS** | 70d | 2016-07-04 | 2016-09-07 |  | 9.43d |  |  | 48,529.77 |
| 49 | 1.4.1 | **Trabajos Preliminares** | 36d | 2016-07-06 | 2016-08-09 |  | 35.43d |  |  | 675.82 |
| 50 | 1.4.1.1 | Trazo y replanteo inicial de la obra | 1d | 2016-08-08 | 2016-08-09 | 30SS | 0.43d | 0d |  | 361.59 |
| 51 | 1.4.1.2 | Replanteo final de la obra | 1d | 2016-07-06 | 2016-07-07 | 91 | 75.43d |  |  | 314.23 |
| 52 | 1.4.2 | **Movimiento de Tierras** | 30d | 2016-08-08 | 2016-09-05 |  | 0.43d |  |  | 6,155.58 |
| 53 | 1.4.2.1 | Excavaciones en terreno normal a pulso hasta 3.00 m profundidad | 7d | 2016-08-08 | 2016-08-15 | 50SS | 0.43d | 0d |  | 2,227.08 |
| 54 | 1.4.2.2 | Refine, nivelación y compactación en terreno normal a pulso | 1d | 2016-08-12 | 2016-08-13 | 53SS+4d | 15.43d | 0d |  | 73.92 |
| 55 | 1.4.2.3 | Relleno con material propio | 1d | 2016-08-18 | 2016-08-19 | 65 | 29.43d |  |  | 35.4 |
| 56 | 1.4.2.4 | Material de préstamo piedra grava de 1/2" - 3/4" (provisión y colocación) | 1d | 2016-09-05 | 2016-09-05 | 68 | 11.43d |  |  | 6.8 |
| 57 | 1.4.2.5 | Eliminación de desmonte en terreno normal R=10 km a pulso | 2d | 2016-08-13 | 2016-08-15 | 54 | 34.43d |  |  | 3,812.38 |

| ID | WBS | Task | Duration | Start | Finish | Predecessors | Total slack | Free slack | Cost |
| --- | --- | --- | --- | --- | --- | --- | --- | --- | --- |
| 58 | 1.4.3 | **Obras de Concreto Simple** | 1d | 2016-08-12 | 2016-08-13 |  | 15.43d |  | 6,225.77 |
| 59 | 1.4.3.1 | Concreto f'c 100 kg/cm2 para solados y/o sub bases (Cemento P-I) | 1d | 2016-08-12 | 2016-08-13 | 54SS | 15.43d | 0d | 6,225.77 |
| 60 | 1.4.4 | **Obras de Concreto Armado** | 26d | 2016-08-11 | 2016-09-05 |  | 0.43d |  | 13,526.84 |
| 61 | 1.4.4.1 | Concreto f'c 210 kg/cm2 para losas de fondo-piso (Cemento P-V) | 2d | 2016-08-13 | 2016-08-15 | 59 | 15.43d | 0d | 2,148.47 |
| 62 | 1.4.4.2 | Encofrado (incl. habilitación de madera) para losas de fondo-piso | 2d | 2016-08-13 | 2016-08-15 | 63SS+2d | 0.43d | 0d | 59.54 |
| 63 | 1.4.4.3 | Acero estruc. trabajado p/losa de fondo- piso (costo prom. incl. desperdicios) | 5d | 2016-08-11 | 2016-08-16 | 53SS+3d | 0.43d | 0d | 777.57 |
| 64 | 1.4.4.4 | Concreto f'c 210 kg/cm2 para muros reforzados (Cemento P-V) | 1d | 2016-08-17 | 2016-08-17 | 65SS+2d | 13.43d | 0d | 3,534.14 |
| 65 | 1.4.4.5 | Encofrado (incl. habilitación de madera) para Muros rectos | 4d | 2016-08-15 | 2016-08-18 | 62 | 0.43d | 0d | 2,186.03 |
| 66 | 1.4.4.6 | Acero estruc. trabajado p/muro reforzado (costo prom. incl. desperdicios) | 3d | 2016-08-13 | 2016-08-16 | 63SS+2d | 12.43d | 0d | 1,802.52 |
| 67 | 1.4.4.7 | Concreto f'c 210 kg/cm2 para losas macizas (Cemento P-V) | 1d | 2016-08-22 | 2016-08-22 | 68SS+3d | 0.43d | 0d | 1,215.02 |
| 68 | 1.4.4.8 | Encofrado (incl. habilitación de madera) para losas macizas | 18d | 2016-08-18 | 2016-09-05 | 65 | 0.43d | 0d | 828.24 |
| 69 | 1.4.4.9 | Acero estruc. trabajado p/losas macizas (costo prom. incl. desperdicios) | 6d | 2016-08-16 | 2016-08-21 | 66 | 12.43d | 0d | 712.33 |
| 70 | 1.4.4.10 | Concreto f'c 210 kg/cm2 para losas removibles (Cemento P-V) | 1d | 2016-08-22 | 2016-08-23 | 71SS | 25.43d | 0d | 91.45 |
| 71 | 1.4.4.11 | Encofrado (incl. habilitación de madera) para losas removibles | 2d | 2016-08-22 | 2016-08-24 | 72 | 12.43d | 0d | 84.36 |
| 72 | 1.4.4.12 | Acero estructural trabajado p/losa removible (costo prom. incl. desperdicios) | 1d | 2016-08-22 | 2016-08-22 | 69 | 12.43d | 0d | 68.96 |
| 73 | 1.4.4.13 | Colocación de losa removible de buzón, cámara o similar | 1d | 2016-08-28 | 2016-08-29 | 82 | 19.43d |  | 18.21 |
| 74 | 1.4.5 | **Revoques, enlucidos y molduras** | 12d | 2016-08-26 | 2016-09-06 |  | 8.43d |  | 1,226.3 |
| 75 | 1.4.5.1 | Solaqueado de muro de concreto con mortero 1:3 | 2d | 2016-09-05 | 2016-09-06 | 68 | 3.43d | 0d | 775.76 |
| 76 | 1.4.5.2 | Tarrajeo exterior con mortero 1:5x1.5 cm para caseta | 3d | 2016-08-26 | 2016-08-29 | 68SS+8d | 17.43d | 0d | 450.54 |
| 77 | 1.4.6 | **Pisos y Pavimentos** | 1d | 2016-09-05 | 2016-09-05 |  | 9.43d |  | 604.97 |
| 78 | 1.4.6.1 | Piso de 2" concreto f'c=140 kg/cm2 de 4 cm + pulido con mortero 1:4 x 1 cm | 1d | 2016-09-05 | 2016-09-05 | 68 | 9.43d | 0d | 604.97 |
| 79 | 1.4.7 | **Carpinteria Metálica y Herreria** | 18d | 2016-08-22 | 2016-09-07 |  | 9.43d |  | 6,108.27 |
| 80 | 1.4.7.1 | Escalera de tubo fo. galvanizado con parantes de 2" por peldaños de 3/4" | 2d | 2016-09-06 | 2016-09-07 | 78 | 9.43d |  | 440.22 |
| 81 | 1.4.7.2 | Perfil metálico "U" de 2"x4"x2"x1/4" para losas removibles | 1d | 2016-08-22 | 2016-08-23 | 70SS | 25.43d |  | 854.49 |
| 82 | 1.4.7.3 | Perfil metálico "L" de 4"x2"x1/4" para losas removibles | 1d | 2016-08-27 | 2016-08-28 | 76SS+1d | 19.43d | 0d | 605.38 |
| 83 | 1.4.7.4 | Parrilla metalica en sumidero - platina de 2"x1/4" | 1d | 2016-08-27 | 2016-08-28 | 84SS | 20.43d |  | 213.53 |
| 84 | 1.4.7.5 | Marco y tapa de acero inox.l DI=0,60 m con mecanismo de seguridad según especificación | 3d | 2016-08-27 | 2016-08-30 | 76SS+1d | 18.43d | 0d | 1,375.69 |
| 85 | 1.4.7.6 | Ventilación con tubería de acero según diseño DN 150 | 2d | 2016-08-29 | 2016-08-31 | 76 | 17.43d | 0d | 308.52 |
| 86 | 1.4.7.7 | Soporte P/tubo DN 150mm | 2d | 2016-08-29 | 2016-08-31 | 85SS | 17.43d |  | 180.2 |
| 87 | 1.4.7.8 | Malla metálica protectora con alambre N° 12 por cocadas de 1" | 1d | 2016-08-29 | 2016-08-30 | 85SS | 18.43d |  | 4.94 |
| 88 | 1.4.7.9 | Ventilación con tubería de PVC DN 150 mm (Salida de Aire) | 1d | 2016-08-22 | 2016-08-22 | 67SS | 26.43d |  | 2,125.3 |

| ID | WBS | Task | Duration | Start | Finish | Predecessors | Total slack | Free slack | Cost |
| --- | --- | --- | --- | --- | --- | --- | --- | --- | --- |
| 89 | 1.4.8 | **Pintura** | 3d | 2016-07-04 | 2016-07-06 |  | 75.43d |  | 735.13 |
| 90 | 1.4.8.1 | Pintura latex dos manos en muros exteriores e interiores | 2d | 2016-07-04 | 2016-07-05 |  | 75.43d | 0d | 612.15 |
| 91 | 1.4.8.2 | Pintura Latex dos manos en cielo raso | 1d | 2016-07-05 | 2016-07-06 | 90 | 75.43d | 0d | 122.98 |
| 92 | 1.4.9 | **Varios: Soporte, pruebas,** | 21d | 2016-08-13 | 2016-09-01 |  | 15.43d |  | 150.45 |
| 93 | 1.4.9.1 | Prueba de calidad del concreto (prueba a la compresión) | 21d | 2016-08-13 | 2016-09-01 | 61SS | 15.43d |  | 150.45 |
| 94 | 1.4.10 | **Instalaciones Electricas** | 21d | 2016-08-18 | 2016-09-06 |  | 10.43d |  | 10,516.37 |
| 95 | 1.4.10.1 | Salida de techo c/cable AWG TW 2.50 mm (14)+d PVC SAP DN 20 mm ( 3/4") (punto) | 1d | 2016-08-22 | 2016-08-23 | 67 | 25.43d |  | 264.42 |
| 96 | 1.4.10.2 | Salida tomacorr. + CT C/AWG TW 2.50 mm (14)+d PVC SAP DN 20 mm ( 3/4") (punto) | 1d | 2016-08-18 | 2016-08-18 | 64 | 13.43d | 0d | 282.54 |
| 97 | 1.4.10.3 | Salida de fuerza para extractor de aire | 1d | 2016-08-18 | 2016-08-18 | 64 | 30.43d |  | 742.05 |
| 98 | 1.4.10.4 | Salida de fuerza para bomba sumidero de desague PVC SAP 20 mm | 1d | 2016-08-18 | 2016-08-18 | 64 | 26.43d | 0d | 743.37 |
| 99 | 1.4.10.5 | Salida de fuerza para motor de 50 HP + PVC-SAP 80 mm adosada + THW 95 mm2 + TW 35 mm2 | 1d | 2016-09-06 | 2016-09-06 | 78 | 10.43d |  | 1,432.62 |
| 100 | 1.4.10.6 | Demolición de losa de piso - vereda (corte y rotura) | 3d | 2016-08-28 | 2016-08-31 | 101 | 17.43d |  | 136.26 |
| 101 | 1.4.10.7 | Buzoneta de Concreto Armado f'c=210 kg/cm² t/normal 70x70x60 cm | 4d | 2016-08-24 | 2016-08-28 | 71 | 12.43d | 0d | 386.6 |
| 102 | 1.4.10.8 | Excavación con interferencia (pulso) en t. normal para instalar cable eléctrico | 3d | 2016-08-28 | 2016-08-31 | 101 | 12.43d | 0d | 151.42 |
| 103 | 1.4.10.9 | Concreto f'c 100 kg/cm2 para solados y/o sub bases (Cemento P-I) | 1d | 2016-08-31 | 2016-09-01 | 102 | 12.43d | 0d | 26.94 |
| 104 | 1.4.10.10 | Relleno compactado de zanja en terreno normal para instalar cable eléctrico | 2d | 2016-09-02 | 2016-09-05 | 110 | 12.43d |  | 177.62 |
| 105 | 1.4.10.11 | Tablero eléctrico gabinete metálico para distribución de 5 circuitos | 2d | 2016-08-27 | 2016-08-29 | 101SS+3d | 19.43d |  | 511.62 |
| 106 | 1.4.10.12 | Placa tomacorriente simple de bakelita t/universal 2 polos c/conexión a tierra | 1d | 2016-09-02 | 2016-09-02 | 96FS+15d | 13.43d | 0d | 88.44 |
| 107 | 1.4.10.13 | Placa interruptor de bakelita simple | 1d | 2016-09-02 | 2016-09-02 | 106SS | 13.43d | 0d | 29.4 |
| 108 | 1.4.10.14 | Fluorescente recto de 2 x 36 W con equipo y pantalla | 1d | 2016-09-02 | 2016-09-03 | 107 | 13.43d |  | 204.96 |
| 109 | 1.4.10.15 | Extractor de aire tipo axial de 1/2 Hp con ducto | 1d | 2016-09-02 | 2016-09-03 | 107 | 13.43d |  | 3,160 |
| 110 | 1.4.10.16 | Acometidad a tablero distribucion ducto P.V.C. SAP DN 25 +cable elect TW 2- 1x4 mm2 | 2d | 2016-09-01 | 2016-09-02 | 103 | 12.43d | 0d | 598.38 |
| 111 | 1.4.10.17 | Pozo conexión a tierra en sistema de bombeo, alumbrado y tomacorriente | 7d | 2016-08-28 | 2016-09-03 | 102SS | 12.43d | 0d | 1,190.06 |
| 112 | 1.4.10.18 | Pruebas eléctricas | 1d | 2016-09-04 | 2016-09-05 | 111 | 12.43d |  | 389.67 |

| ID | WBS | Task | Duration | Start | Finish | Predecessors | Total slack | Free slack | Cost |
| --- | --- | --- | --- | --- | --- | --- | --- | --- | --- |
| 113 | 1.4.11 | **Instalaciones Sanitarias** | 4d | 2016-08-18 | 2016-08-22 |  | 26.43d |  | 2,604.27 |
| 114 | 1.4.11.1 | Electrobomba Sumergible tipo sumidero (1HP) | 1d | 2016-08-18 | 2016-08-19 | 98 | 29.43d | 0d | 2,044.9 |
| 115 | 1.4.11.2 | Reducción de P.V.C. tipo unión roscada DN 50 a 25 mm | 1d | 2016-08-18 | 2016-08-19 | 98 | 28.43d | 0d | 6.9 |
| 116 | 1.4.11.3 | Codo de PVC-C10 simple presión de 90° DN 25 | 1d | 2016-08-19 | 2016-08-20 | 115 | 28.43d |  | 10.15 |
| 117 | 1.4.11.4 | Union Presion Rosca DN 25 mm | 1d | 2016-08-19 | 2016-08-20 | 115 | 28.43d | 0d | 7.5 |
| 118 | 1.4.11.5 | Válvula compuerta de bronce roscada DN 25 + Accesorios | 1d | 2016-08-19 | 2016-08-20 | 117SS | 28.43d | 0d | 44.93 |
| 119 | 1.4.11.6 | Válvula check de bronce unión roscad DN 25 | 1d | 2016-08-19 | 2016-08-20 | 118SS | 28.43d |  | 26.75 |
| 120 | 1.4.11.7 | Tuberia de PVC Clase 10 SP DN 25 mm | 1d | 2016-08-18 | 2016-08-19 | 114SS | 29.43d |  | 160.68 |
| 121 | 1.4.11.8 | Excavación con interferencia (pulso) en t. normal de 0.60x0.65 m | 1d | 2016-08-18 | 2016-08-19 | 98 | 26.43d | 0d | 93.7 |
| 122 | 1.4.11.9 | Relleno compactado de zanja en terreno normal para instalar tub. agua | 2d | 2016-08-19 | 2016-08-21 | 121 | 27.43d | 0d | 109.92 |
| 123 | 1.4.11.10 | Concreto f'c 210kg/cm2 para columnas (cemento P-V) | 1d | 2016-08-19 | 2016-08-20 | 122SS | 28.43d |  | 17.31 |
| 124 | 1.4.11.11 | Encofrado (incl. habilitación de madera) para columas acabado caravista | 2d | 2016-08-20 | 2016-08-22 | 125 | 26.43d |  | 69.07 |
| 125 | 1.4.11.12 | Acero estructural trabajado p/columnas (costo prom. i/desperdic.) | 1d | 2016-08-19 | 2016-08-20 | 121 | 26.43d | 0d | 12.46 |
| 126 | 1.5 | **CONSTRUCCION DE ACCESO A CASETA** | 79d | 2016-07-04 | 2016-09-16 |  | 0.43d |  | 25,158.24 |
| 127 | 1.5.1 | **Obras Preliminares** | 26d | 2016-08-22 | 2016-09-16 |  | 0.43d |  | 675.82 |
| 128 | 1.5.1.1 | Trazo y replanteo inicial de la obra | 1d | 2016-08-22 | 2016-08-23 | 67 | 0.43d | 0d | 361.59 |
| 129 | 1.5.1.2 | Replanteo final de la obra | 1d | 2016-09-15 | 2016-09-16 | 153 | 0.43d |  | 314.23 |
| 130 | 1.5.2 | **Trabajos Preliminares** | 6d | 2016-07-04 | 2016-07-09 |  | 0.43d |  | 931.98 |
| 131 | 1.5.2.1 | Demolición de muros de concreto armado | 4d | 2016-07-04 | 2016-07-07 |  | 0.43d | 0d | 771.97 |
| 132 | 1.5.2.2 | Demolición de losa de piso - vereda (corte y rotura) | 2d | 2016-07-07 | 2016-07-09 | 131 | 73.43d |  | 160.01 |
| 133 | 1.5.3 | **Movimiento de Tierras** | 22d | 2016-08-22 | 2016-09-12 |  | 0.43d |  | 2,627.24 |
| 134 | 1.5.3.1 | Excavaciones en terreno normal a pulso hasta 3.00 m profundidad | 5d | 2016-08-22 | 2016-08-27 | 128SS | 0.43d | 0d | 740.55 |
| 135 | 1.5.3.2 | Relleno con material propio | 3d | 2016-09-07 | 2016-09-10 | 143 | 4.43d | 0d | 78.92 |
| 136 | 1.5.3.3 | Eliminación de desmonte en terreno normal R=10 km a pulso | 2d | 2016-09-10 | 2016-09-12 | 135 | 4.43d |  | 1,807.77 |

| ID | WBS | Task | Duration | Start | Finish | Predecessors | Total slack | Free slack | Cost |
| --- | --- | --- | --- | --- | --- | --- | --- | --- | --- |
| 137 | 1.5.4 | **Obras de Concreto Simple** | 3d | 2016-08-26 | 2016-08-29 |  | 19.43d |  | 4,808.22 |
| 138 | 1.5.4.1 | Concreto f'c 100 kg/cm2 para solados y/o sub bases (Cemento P-I) | 3d | 2016-08-26 | 2016-08-29 | 134SS+4d | 19.43d |  | 4,808.22 |
| 139 | 1.5.5 | **Obras de Concreto Armado** | 15d | 2016-08-27 | 2016-09-10 |  | 0.43d |  | 11,999.69 |
| 140 | 1.5.5.1 | Concreto f'c 210 kg/cm2 para losas de fondo-piso (Cemento P-V) | 1d | 2016-09-08 | 2016-09-09 | 141SS+1d | 7.43d |  | 2,793.41 |
| 141 | 1.5.5.2 | Encofrado (incl. habilitación de madera) para losas de fondo-piso | 3d | 2016-09-07 | 2016-09-10 | 142SS+1d | 2.29d | 0d | 46.88 |
| 142 | 1.5.5.3 | Acero estruc. trabajado p/losa de fondo- piso (costo prom. incl. desperdicios) | 3d | 2016-09-06 | 2016-09-09 | 144SS+8d | 2.29d | 0d | 1,140.7 |
| 143 | 1.5.5.4 | Concreto f'c 210 kg/cm2 para muros reforzados (Cemento P-V) | 7d | 2016-09-01 | 2016-09-07 | 144SS+2d | 4.43d | 0d | 4,232.03 |
| 144 | 1.5.5.5 | Encofrado (incl. habilitación de madera) para Muros rectos | 10d | 2016-08-30 | 2016-09-08 | 145SS+3d | 0.43d | 0d | 2,784.71 |
| 145 | 1.5.5.6 | Acero estruc. trabajado p/muro reforzado (costo prom. incl. desperdicios) | 5d | 2016-08-27 | 2016-09-01 | 134SS+5d | 0.43d | 0d | 1,001.96 |
| 146 | 1.5.6 | **Revoques, enlucidos y molduras** | 3d | 2016-09-08 | 2016-09-11 |  | 5.43d |  | 696.14 |
| 147 | 1.5.6.1 | Tarrajeo con mortero 1:5x1.5 cm para muros exteriores | 3d | 2016-09-08 | 2016-09-11 | 144 | 5.43d |  | 696.14 |
| 148 | 1.5.7 | **Pisos y Pavimentos** | 6d | 2016-09-06 | 2016-09-12 |  | 4.43d |  | 3,127.42 |
| 149 | 1.5.7.1 | Afirmado de 8" para pisos, patios, y veredas compactado | 2d | 2016-09-06 | 2016-09-08 | 142SS | 8.43d |  | 1,221.96 |
| 150 | 1.5.7.2 | Piso de adoquin de concreto de 20x10x4 cm - Transito Peatonal | 2d | 2016-09-08 | 2016-09-10 | 144 | 4.43d | 0d | 758.27 |
| 151 | 1.5.7.3 | Piso de gramoquin de concreto de 20x20x8 cm | 2d | 2016-09-10 | 2016-09-12 | 150 | 4.43d |  | 1,147.19 |
| 152 | 1.5.8 | **Pintura** | 2d | 2016-09-13 | 2016-09-15 |  | 0.43d |  | 291.73 |
| 153 | 1.5.8.1 | Pintura latex dos manos en muros exteriores | 2d | 2016-09-13 | 2016-09-15 | 144FS+5d | 0.43d | 0d | 291.73 |
